# Final Gantt Chart

Schedule from MS Project, 2007-01-16 to 2007-03-01.
University of Notre Dame

## Calendars

- Standard: Mon-Sun 08:00-12:00, 13:00-17:00.

## Resources

| Resource |
| --- |
| Matt |
| Mario |
| Jeff |
| Clem |

## Schedule

| ID | Task | Duration | Start | Finish | Predecessors | Total slack | Constraint | Resources | Work |
| --- | --- | --- | --- | --- | --- | --- | --- | --- | --- |
| 1 | Pick up microcontroller and Xbee | 2d | 2007-01-16 | 2007-01-17 |  | 1d |  | Mario | 16h |
| 2 | Figure out microcontroller and Zigbee | 21d | 2007-01-19 | 2007-02-08 | 1 | 0d | finish no earlier than 2007-02-08 | Mario; Matt; Jeff | 504h |
| 3 | Convert Tinyos code to C | 21d | 2007-01-16 | 2007-02-05 |  | 3d |  | Matt; Jeff | 336h |
| 4 | Research variance transmitters and beacons | 7d | 2007-01-16 | 2007-01-22 |  | 17d |  | Matt | 56h |
| 5 | Integrate code with microcontroller and Zigbees | 21d | 2007-02-09 | 2007-03-01 | 2, 4, 3 | 0d |  | Mario; Matt; Jeff | 504h |
| 6 | Order parts for the hovercrafts | 7d | 2007-01-16 | 2007-01-22 |  | 17d |  | Mario | 56h |
| 7 | Build the hovercrafts | 21d | 2007-02-09 | 2007-03-01 | 6 | 0d | start no earlier than 2007-02-09 | Clem; Jeff | 336h |
| 8 | Research the H-Bridge | 7d | 2007-01-16 | 2007-01-22 |  | 17d |  | Clem | 56h |
| 9 | Build and test the H-Bridge | 21d | 2007-02-09 | 2007-03-01 | 8 | 0d | start no earlier than 2007-02-09 | Clem; Mario | 336h |
| 10 | Research the motor situation | 7d | 2007-01-16 | 2007-01-22 |  | 17d |  | Matt | 56h |
| 11 | Build and test the motors | 21d | 2007-02-09 | 2007-03-01 | 10 | 0d | start no earlier than 2007-02-09 | Clem; Matt | 336h |

Notes:
- 1: Mario will pick up the Xbee transmitters and the microcontroller.
- 2: Mario, Matt, and Jeff will figure out how to integrate the transmitters with the microcontroller.
- 3: Jeff and Matt will convert the Tinyos code developed in the first semester to the C code utilized by the microcontroller.
- 4: Matt will research the various kinds of transmitters which can be used (Telos, Xbee, Chipcon, etc).
- 5: Matt, Jeff, and Mario will integrate the code with the microcontroller / transmitter system and test to ensure that it works.
- 6: Mario will order the necessary parts for the construction of 2 to 4 hovercrafts.
- 7: Jeff and Clem will build the hovercrafts.
- 8: Clement will research the technology necessary to implement an H-bridge, and then will order the necessary parts.
- 9: Clem and Mario will build the H-bridge.
- 10: Clem will research the motor situation, i.e. whether to continue to use two thrust fans or to use one motor with a rudder / servo combination.
- 11: Matt and Clem will build and test the motors.
